# Proy. Chullo Oxani 2000-2003

Schedule from MS Project, 2013-04-01 to 2013-09-17.
Hewlett-Packard Company

## Calendars

- Estándar: Mon-Fri 09:00-13:00, 15:00-19:00; Sat-Sun off.

## Resources

| Resource |
| --- |
| Albañil 1 |
| Albañil 2 |
| Albañil 3 |
| Ayudante 1 |
| Ayudante 2 |
| Ayudante 3 |
| Ayudante 4 |
| Ayudante 5 |
| Ayudante 6 |
| Ayudante 7 |
| Ayudante 8 |
| Operador 1 |
| Encofrador 1 |
| Encofrador 2 |
| Encofrador 3 |
| Armador 1 |
| Armador 2 |
| Plomero |
| Vibradora 1 |
| Vibradora 2 |
| Topografo 1 |
| Alarife 1 |
| Alarife 2 |
| Topografo 2 |
| Volqueta |
| Camioneta |
| Hormigonera 1 |
| Hormigonera 2 |
| Vibradora 3 |
| Vibradora 4 |
| Nivel 1 |
| Nivel 2 |
| Chofer |
| Ayudante 9 |
| Ayudante 10 |
| Ayudante 11 |
| Ayudante 12 |
| Encofrador 4 |
| Encofrador 5 |
| Encofrador 6 |
| Albañil 4 |
| Albañil 5 |
| Albañil 6 |
| Albañil 7 |
| Ayudante 13 |
| Ayudante 14 |
| Ayudante 15 |
| Ayudante 21 |
| Ayudante 16 |
| Ayudante 17 |
| Ayudante 18 |
| Ayudante 19 |
| Ayudante 20 |
| Ayudante 22 |
| Ayudante 23 |
| Ayudante 24 |
| Ayudante 25 |
| Ayudante 26 |
| Ayudante 27 |
| Ayudante 28 |
| Ayudante 29 |
| Ayudante 30 |
| Ayudante 31 |
| Ayudante 32 |
| Ayudante 33 |
| Ayudante 34 |
| Ayudante 35 |
| Hormigonera 3 |
| Hormigonera 4 |
| Especialista 1 |
| Soldador 1 |
| Soldador 2 |
| Especialista 2 |
| Hormigonera 5 |
| Hormigonera 6 |
| Hormigonera 7 |
| Vibradora 5 |
| Vibradora 6 |
| Vibradora 7 |
| Encofrador 7 |
| Albañil 9 |
| Albañil 8 |
| Albañil 11 |
| Albañil 10 |
| Albañil 13 |
| Albañil 12 |
| Ayudante 36 |
| Ayudante 37 |
| Ayudante 38 |
| Ayudante 39 |
| Ayudante 40 |
| Ayudante 41 |
| Ayudante 42 |
| Ayudante 43 |
| Ayudante 44 |
| Ayudante 45 |
| Ayudante 46 |
| Ayudante 47 |
| Ayudante 48 |
| Ayudante 49 |
| Ayudante 50 |
| Ayudante 51 |
| Ayudante 52 |
| Encofrador 8 |
| Vibradora 8 |
| Hormigonera 8 |
| Ayudante 53 |

## Schedule

| ID | WBS | Task | Duration | Start | Finish | Predecessors | Total slack | Free slack | Constraint | Resources | Work |
| --- | --- | --- | --- | --- | --- | --- | --- | --- | --- | --- | --- |
| 1 | 1 | **PROYECTO DE RIEGO CHULLO OXANI** | 122d | 2013-04-01 | 2013-09-17 |  | 0d |  |  |  | 51983.6h |
| 2 | 1.1 | **INSTALACIONES GENERALES** | 55d | 2013-04-01 | 2013-06-14 |  | 0d |  |  |  | 1792h |
| 3 | 1.1.1 | Movilización de equipos | 14d | 2013-04-01 | 2013-04-18 |  | 0d |  | start no earlier than 2013-04-01 |  |  |
| 4 | 1.1.2 | Instalación de Faenas | 4d | 2013-04-02 | 2013-04-05 | 3SS+1d | 0d |  |  | Albañil 1; Ayudante 1; Ayudante 2; Albañil 2; Camioneta; Chofer | 192h |
| 5 | 1.1.3 | Acopio y disposición de materiales | 50d | 2013-04-08 | 2013-06-14 | 4 | 67d |  |  | Camioneta; Volqueta; Chofer; Operador 1 | 1600h |
| 6 | 1.2 | **REPLANTEO Y TRAZADO** | 15d | 2013-04-08 | 2013-04-26 |  | 0d |  |  |  | 704h |
| 7 | 1.2.1 | Replanteo Estructuras Hidráulicas | 7d | 2013-04-08 | 2013-04-16 | 4 | 0d |  |  | Alarife 1; Topografo 1; Nivel 1; Ayudante 1 | 224h |
| 8 | 1.2.2 | Replanteo de Canales | 15d | 2013-04-08 | 2013-04-26 | 7SS | 0d |  |  | Ayudante 2; Alarife 2; Topografo 2; Nivel 2 | 480h |
| 9 | 1.3 | **OBRA DE TOMA** | 43d | 2013-04-11 | 2013-06-10 |  | 7d | 0d |  |  | 5088h |
| 10 | 1.3.1 | Excavación (0-2 m) con bomba de agua | 10d | 2013-04-11 | 2013-04-24 | 7SS+3d | 7d | 0d |  | Ayudante 3; Albañil 1; Albañil 10; Albañil 4; Ayudante 6; Ayudante 7 | 480h |
| 11 | 1.3.2 | H°C° Fundaciones (1:2:4) 50% Piedra Desplazadora | 16d | 2013-04-25 | 2013-05-16 | 10 | 7d | 0d |  | Encofrador 1; Ayudante 7; Ayudante 6; Albañil 7; Albañil 6; Ayudante 3; Albañil 4; Hormigonera 2; Encofrador 2; Hormigonera 1; Vibradora 1; Vibradora 2 | 1536h |
| 12 | 1.3.3 | H°C° Elevaciones (1:2:4) 50% Piedra Desplazadora | 16d | 2013-04-29 | 2013-05-20 | 11SS+2d | 7d | 0d |  | Vibradora 4; Vibradora 3; Albañil 13; Ayudante 8; Albañil 10; Ayudante 2; Ayudante 11; Ayudante 12; Ayudante 13; Encofrador 7; Hormigonera 3; Hormigonera 4 | 1536h |
| 13 | 1.3.4 | Hormigón armado H21 | 10d | 2013-05-21 | 2013-06-03 | 12 | 46d | 0d |  | Albañil 2; Albañil 6; Armador 1; Armador 2; Ayudante 41; Ayudante 30; Ayudante 11; Ayudante 8; Vibradora 3; Encofrador 1; Hormigonera 1 | 864h |
| 14 | 1.3.5 | Provisión y colocación de Accesorios de obra de toma | 6d | 2013-05-24 | 2013-05-31 | 13SS+3d | 46d | 0d |  | Albañil 10; Ayudante 3; Ayudante 13; Plomero | 192h |
| 15 | 1.3.6 | Revoque de mortero con aditivo impermeabilizante 1:3 E=2 cm | 10d | 2013-05-21 | 2013-06-03 | 14FF+1d | 46d | 0d |  | Albañil 9; Ayudante 9; Albañil 13; Ayudante 2 | 320h |
| 16 | 1.3.7 | Revoque exterior con cemento | 5d | 2013-06-04 | 2013-06-10 | 15 | 46d | 0d |  | Albañil 8; Ayudante 3; Albañil 2; Ayudante 2 | 160h |
| 17 | 1.4 | **MURO DE CONTENCIÓN** | 30d | 2013-04-17 | 2013-05-28 |  | 80d |  |  |  | 2640h |
| 18 | 1.4.1 | Excavación (0-2 m) suelo semiduro | 10d | 2013-04-17 | 2013-04-30 | 7 | 80d | 0d |  | Ayudante 1; Albañil 2; Ayudante 9; Ayudante 10; Ayudante 4; Ayudante 5; Albañil 8; Albañil 9 | 640h |
| 19 | 1.4.2 | H°C° Fundaciones (1:2:4) 50% Piedra Desplazadora | 10d | 2013-05-01 | 2013-05-14 | 18 | 80d | 0d |  | Ayudante 21; Ayudante 20; Ayudante 30; Ayudante 24; Ayudante 9; Ayudante 37; Encofrador 4; Vibradora 7; Vibradora 5; Hormigonera 5 | 800h |
| 20 | 1.4.3 | Muro de mampostería de piedra bruta Elevaciones | 15d | 2013-05-08 | 2013-05-28 | 19SS+5d | 80d |  |  | Albañil 8; Albañil 12; Ayudante 4; Ayudante 52; Ayudante 39; Ayudante 5; Ayudante 10; Encofrador 6; Encofrador 5; Hormigonera 7 | 1200h |
| 21 | 1.5 | **DESARENADOR** | 25d | 2013-06-11 | 2013-07-15 |  | 46d |  |  |  | 1424h |
| 22 | 1.5.1 | Excavación (0-2 m) suelo semiduro | 2d | 2013-06-11 | 2013-06-12 | 16 | 46d | 0d |  | Ayudante 49; Albañil 8; Ayudante 11; Ayudante 34; Ayudante 39 | 80h |
| 23 | 1.5.2 | H°C° Fundaciones (1:2:4) 50% Piedra Desplazadora | 7d | 2013-06-13 | 2013-06-21 | 22 | 46d | 0d |  | Ayudante 11; Ayudante 6; Ayudante 49; Ayudante 52; Ayudante 39; Ayudante 3; Encofrador 7; Vibradora 7; Vibradora 5; Hormigonera 8 | 560h |
| 24 | 1.5.3 | H°C° Elevaciones (1:2:4) 50% Piedra Desplazadora | 6d | 2013-06-24 | 2013-07-01 | 23 | 46d | 0d |  | Albañil 10; Albañil 6; Ayudante 11; Ayudante 3; Ayudante 13; Ayudante 49; Ayudante 39; Encofrador 7; Encofrador 4; Hormigonera 7 | 480h |
| 25 | 1.5.4 | Hormigón armado H21 | 3d | 2013-07-02 | 2013-07-04 | 24 | 46d | 0d |  | Albañil 9; Armador 1; Ayudante 34; Ayudante 8; Vibradora 4; Encofrador 8; Hormigonera 2 | 156h |
| 26 | 1.5.5 | Provisión e instalación de accesorios de Desarenador | 2d | 2013-07-05 | 2013-07-08 | 25 | 46d | 0d |  | Albañil 9; Ayudante 6; Ayudante 8; Plomero | 56h |
| 27 | 1.5.6 | Instalación de Compuertas y Rejillas | 2d | 2013-07-09 | 2013-07-10 | 26 | 46d | 0d |  | Especialista 2; Ayudante 4 | 20h |
| 28 | 1.5.7 | Revoque interior con cemento | 3d | 2013-07-11 | 2013-07-15 | 27 | 46d |  |  | Albañil 6; Ayudante 6; Ayudante 49 | 72h |

| ID | WBS | Task | Duration | Start | Finish | Predecessors | Total slack | Free slack | Resources | Work |
| --- | --- | --- | --- | --- | --- | --- | --- | --- | --- | --- |
| 29 | 1.6 | **CANAL DE HORMIGÓN CICLÓPEO** | 115d | 2013-04-03 | 2013-09-10 |  | 0d |  |  | 24267.6h |
| 30 | 1.6.1 | Excavación (0-2 m) suelo semiduro | 20d | 2013-04-03 | 2013-04-30 | 8FF+2d | 0d |  | Albañil 5; Albañil 3; Ayudante 30; Ayudante 31; Ayudante 32; Ayudante 37; Ayudante 34; Ayudante 36 | 1280h |
| 31 | 1.6.2 | H°C° Fundaciones (1:2:4) 50% Piedra Desplazadora | 90d | 2013-05-01 | 2013-09-03 | 30 | 0d |  | Ayudante 25; Ayudante 14; Ayudante 19; Ayudante 33; Ayudante 15; Albañil 5; Encofrador 3; Vibradora 6; Vibradora 8; Hormigonera 6; Ayudante 22; Ayudante 40; Ayudante 41; Ayudante 42; Ayudante 43 | 10600h |
| 32 | 1.6.3 | H°C° Elevaciones (1:2:4) 50% Piedra Desplazadora | 90d | 2013-05-08 | 2013-09-10 | 31SS+5d | 0d |  | Ayudante 16; Ayudante 29; Ayudante 28; Ayudante 26; Ayudante 27; Albañil 11; Ayudante 44; Ayudante 45 | 5760h |
| 33 | 1.6.4 | Revoque interior con cemento | 80d | 2013-05-10 | 2013-08-29 | 32SS+2d | 8d |  | Albañil 3; Ayudante 17; Ayudante 18; Ayudante 46; Ayudante 47; Ayudante 48 | 3832.33h |
| 34 | 1.6.5 | Juntas de Dilatación | 90d | 2013-05-01 | 2013-09-03 | 30 | 5d |  | Albañil 1; Ayudante 1; Especialista 2; Ayudante 50; Ayudante 51 | 2795.29h |
| 35 | 1.7 | **CÁMARAS REPARTIDORAS** | 79d | 2013-05-21 | 2013-09-06 |  | 7d |  |  | 13100h |
| 36 | 1.7.1 | Excavación (0-2 m) suelo semiduro | 45d | 2013-05-21 | 2013-07-22 | 12 | 7d | 0d | Ayudante 12 | 360h |
| 37 | 1.7.2 | H°C° Fundaciones (1:2:4) 50% Piedra Desplazadora | 50d | 2013-05-28 | 2013-08-05 | 36SS+5d | 7d | 0d | Ayudante 23; Ayudante 7; Ayudante 36; Ayudante 24; Ayudante 20; Ayudante 21; Encofrador 2; Vibradora 1; Vibradora 2; Hormigonera 3 | 4000h |
| 38 | 1.7.3 | H°C° Elevaciones (1:2:4) 50% Piedra Desplazadora | 60d | 2013-05-31 | 2013-08-22 | 37SS+3d | 7d | 0d | Albañil 7; Albañil 4; Ayudante 32; Ayudante 37; Ayudante 31; Ayudante 38; Ayudante 35; Encofrador 6; Encofrador 5; Hormigonera 5 | 4800h |
| 39 | 1.7.4 | Hormigón armado H21 | 60d | 2013-06-17 | 2013-09-06 | 38SS+11d | 7d |  | Albañil 8; Armador 1; Ayudante 9; Ayudante 2; Vibradora 3; Encofrador 1; Hormigonera 1 | 3348h |
| 40 | 1.7.5 | Instalación de Compuertas y Rejillas | 50d | 2013-06-04 | 2013-08-12 | 38SS+2d | 26d |  | Especialista 2; Ayudante 5 | 592h |
| 41 | 1.8 | **MEDIDOR DE CAUDALES** | 4d | 2013-06-11 | 2013-06-14 |  | 67d |  |  | 128h |
| 42 | 1.8.1 | Medidor RBC | 4d | 2013-06-11 | 2013-06-14 | 9 | 67d |  | Albañil 2; Albañil 9; Ayudante 10; Ayudante 2 | 128h |
| 43 | 1.9 | **ACUEDUCTO TIPO PUENTE COLGANTE** | 45d | 2013-04-08 | 2013-06-07 |  | 72d |  |  | 2360h |
| 44 | 1.9.1 | Excavación (0-2 m) suelo semiduro | 10d | 2013-05-01 | 2013-05-14 | 18 | 86d | 0d | Albañil 2; Ayudante 36; Ayudante 38; Ayudante 31; Ayudante 32; Ayudante 35; Ayudante 34; Ayudante 41 | 640h |
| 45 | 1.9.2 | H°C° Fundaciones (1:2:4) 50% Piedra Desplazadora | 4d | 2013-05-15 | 2013-05-20 | 44FF+4d | 86d |  | Albañil 2; Ayudante 24; Ayudante 20; Ayudante 31; Ayudante 32; Ayudante 23; Ayudante 34; Ayudante 30; Armador 1; Encofrador 4; Encofrador 8; Hormigonera 5; Hormigonera 8 | 416h |
| 46 | 1.9.3 | Preparación Estructura Puente Colgante | 40d | 2013-04-08 | 2013-05-31 | 4 | 72d | 0d | Especialista 1; Soldador 1; Soldador 2 | 956h |
| 47 | 1.9.4 | Instalación de Puente colgante | 3d | 2013-05-31 | 2013-06-04 | 46FF+2d | 72d | 0d | Albañil 12; Ayudante 52; Ayudante 6; Ayudante 53; Ayudante 39; Ayudante 49; Ayudante 34; Ayudante 4; Armador 1; Especialista 1; Armador 2 | 240h |
| 48 | 1.9.5 | Provisión y Colocado de tubería PVC de 8" | 1d | 2013-06-05 | 2013-06-05 | 47 | 72d | 0d | Ayudante 34; Ayudante 13; Ayudante 49; Ayudante 39; Especialista 1; Plomero | 48h |
| 49 | 1.9.6 | Prueba Hidráulica | 2d | 2013-06-06 | 2013-06-07 | 48 | 72d | 0d | Ayudante 34; Especialista 2; Plomero | 28h |
| 50 | 1.9.7 | Tesado y ajustes finales | 1d | 2013-06-06 | 2013-06-06 | 49SS | 73d |  | Ayudante 52; Ayudante 39; Ayudante 6; Especialista 1 | 32h |
| 51 | 1.10 | LIMPIEZA GENERAL | 5d | 2013-09-11 | 2013-09-17 | 29 | 0d |  | Ayudante 1; Ayudante 2; Ayudante 3; Ayudante 4; Ayudante 5; Ayudante 6; Ayudante 7; Ayudante 8; Camioneta; Chofer; Operador 1; Volqueta | 480h |
